# 2-2

Schedule from MS Project, 2023-12-14 to 2024-04-15, 2 hours a day, costs in €, A marks actual dates.
Universite Clermont Auvergne

## Calendars

- SAE: Mon 08:00-10:00, 13:30-17:30; Tue 08:00-10:00; Wed 08:00-10:00, 13:30-16:30; Thu 08:00-10:00; Fri 08:00-10:00, 13:30-16:30; Sat-Sun off. Exceptions (off unless hours are given): 2024-01-03 to 2024-01-07 08:00-10:00, 13:30-16:30, 2024-01-08 to 2024-01-13 08:00-10:00, 13:30-17:30, 2024-03-25 to 2024-04-03 08:00-12:00, 13:30-16:30.

## Resources

| Resource | Rate |
| --- | --- |
| A_PE | 20 |
| K_MO | 20 |
| P_LE | 20 |
| D_DA | 20 |
| A_PI | 20 |

## Schedule

| ID | WBS | Task | Duration | Start | Finish | Predecessors | Complete | Remaining | Baseline start | Baseline finish | Baseline duration | Total slack | Free slack | Constraint | Resources | Work | Actual work | Cost | Baseline cost | Actual cost |
| --- | --- | --- | --- | --- | --- | --- | --- | --- | --- | --- | --- | --- | --- | --- | --- | --- | --- | --- | --- | --- |
| 1 | 1 | **Étude de courbes de fréquence cardiaque** | 207.14d | 2023-12-14 A | 2024-04-15 |  | 18% | 168.91d | 2023-09-15 | 2024-04-04 | 144.83d | 0d |  |  |  | 501.09h | 78.22h | 10,021.8 | 11,159.78 | 1,564.37 |
| 2 | 1.1 | **1 - Management de projet** | 93.5d | 2023-12-15 | 2024-02-08 |  |  |  | 2023-09-15 | 2024-04-04 | 144.83d | 112.99d |  |  |  | 120h |  | 2,400 | 3,320 |  |
| 3 | 1.1.1 | **1.1 - Recueil de besoins** | 17d | 2023-12-15 | 2023-12-27 |  |  |  | 2023-09-15 | 2023-10-16 | 21.75d | 189.49d |  |  |  | 40h |  | 800 | 1,500 |  |
| 4 | 1.1.1.1 | **1.1.5 - Rendez vous** | 17d | 2023-12-15 | 2023-12-27 |  |  |  | 2023-09-15 | 2023-09-21 | 4.75d | 189.49d |  |  |  | 40h |  | 800 | 420 |  |
| 5 | 1.1.1.1.1 | 1.1.5.2 - Avec le tuteur | 12h | 2023-12-16 | 2023-12-26 |  |  |  |  |  |  | 160.54d |  |  | A_PE; A_PI; D_DA; K_MO; P_LE | 15h |  | 300 |  |  |
| 6 | 1.1.1.1.2 | 1.1.5.4 - Avec le client | 19h | 2023-12-15 | 2023-12-27 |  |  |  |  |  |  | 159.54d |  |  | A_PE; A_PI; D_DA; K_MO; P_LE | 25h |  | 500 |  |  |
| 7 | 1.1.2 | **1.4 - Suivi de projet** | 37d | 2024-01-15 | 2024-02-08 |  |  |  | 2023-10-12 | 2024-04-04 | 125.58d | 112.99d |  |  |  | 80h |  | 1,600 | 1,180 |  |
| 8 | 1.1.2.1 | 1.4.4 - Préparation des rapports globaux | 16h | 2024-01-22 | 2024-02-06 | 10 |  |  |  |  |  | 83.04d | 0d | start no earlier than 2024-01-22 | A_PE; A_PI; D_DA; K_MO; P_LE | 40h |  | 800 |  |  |
| 9 | 1.1.2.2 | 1.4.5 - Préparation des vidéos | 6h | 2024-02-07 | 2024-02-08 | 8 |  |  |  |  |  | 83.04d |  |  | A_PE; A_PI; D_DA; K_MO; P_LE | 30h |  | 600 |  |  |
| 10 | 1.1.2.3 | 1.4.9 - GANTT réel | 10h | 2024-01-15 | 2024-01-17 |  |  |  |  |  |  | 108.04d | 5d | start no earlier than 2024-01-15 | A_PE | 10h |  | 200 |  |  |
| 11 | 1.2 | **2 - Développement** | 207.14d | 2023-12-14 A | 2024-04-15 |  | 22% | 160.55d | 2023-09-20 | 2024-02-26 | 112.75d | 0d |  |  |  | 381.09h | 78.22h | 7,621.8 | 7,839.78 | 1,564.37 |
| 12 | 1.2.1 | **2.1 - Conception** | 114.15d | 2023-12-15 A | 2024-02-22 |  | 1% | 113.17d | 2023-09-20 | 2023-12-15 | 62.1d | 92.84d |  |  |  | 160h | 0.7h | 3,200 | 1,544.62 | 14 |
| 13 | 1.2.1.1 | 2.1.1 - Communication (reseaux) | 7h | 2023-12-15 A | 2024-02-22 | 14 | 10% | 6.3h | 2023-11-15 | 2023-12-15 | 7h | 92.84d |  |  | A_PE; P_LE | 7h | 0.7h | 140 | 140 | 14 |
| 14 | 1.2.1.2 | 2.1.3 - Architecture Blazor | 13.5h | 2024-01-01 | 2024-01-04 |  |  |  |  |  |  | 0d |  | start no earlier than 2024-01-01 | A_PE; A_PI | 20h |  | 400 |  |  |
| 15 | 1.2.1.3 | 2.1.4 - Architecture Kotlin | 40h | 2024-01-29 | 2024-02-09 | 14 |  |  |  |  |  | 65.04d | 0d | start no earlier than 2024-01-29 | A_PE; A_PI; D_DA; K_MO; P_LE | 100h |  | 2,000 |  |  |
| 16 | 1.2.1.4 | 2.1.6 - Diagramme de classes | 15h | 2024-02-12 | 2024-02-20 | 15 |  |  |  |  |  | 65.04d | 0d |  | A_PE; A_PI; D_DA; K_MO; P_LE | 27h |  | 540 |  |  |
| 17 | 1.2.1.5 | 2.1.8 - Maquettes Kotlin | 6h | 2024-02-12 | 2024-02-14 | 15 |  |  |  |  |  | 75.04d |  |  | A_PI | 6h |  | 120 |  |  |
| 18 | 1.2.2 | **2.2 - Client Web et Mobile** | 112d | 2023-12-15 A | 2024-02-21 |  | 70% | 33.33d | 2023-11-15 | 2024-02-05 | 58.14d | 94.99d |  |  |  | 67.52h | 45.41h | 1,350.47 | 2,937.27 | 908.27 |
| 19 | 1.2.2.1 | 2.2.1 - Interface utilisateur client (Vues) WEB | 15h | 2023-12-15 A | 2024-01-15 |  | 85% | 2.25h | 2023-11-20 | 2024-01-09 | 15h | 147.29d |  |  | A_PI | 15h | 12.75h | 300 | 300 | 255 |
| 20 | 1.2.2.2 | 2.2.2 - Gestion des données client | 40.22h | 2023-12-15 A | 2024-02-19 |  | 80% | 7.86h | 2023-11-15 | 2023-12-13 | 40h | 99.2d |  |  | A_PE; D_DA; P_LE | 40.52h | 32.66h | 810.47 | 2,167.27 | 653.27 |
| 21 | 1.2.2.3 | 2.2.4 - Authentification Mobile Client | 3h | 2024-02-20 | 2024-02-21 | 15, 16 |  |  |  |  |  | 65.04d |  | start no earlier than 2023-12-11 | A_PE; D_DA | 6h |  | 120 |  |  |
| 22 | 1.2.2.4 | 2.2.6 - Définitions des algoritmes d'analyse de la fréquence cardiaque | 6h | 2023-12-18 | 2023-12-25 |  |  |  | 2023-12-15 | 2023-12-22 | 0h | 162.27d |  | start no earlier than 2023-12-18 | D_DA; A_PE | 6h |  | 120 |  |  |
| 23 | 1.2.3 | **2.3 - Web admin et monitorin** | 7.25d | 2024-01-04 | 2024-01-06 |  |  |  | 2023-11-22 | 2024-01-01 | 27.38d | 170.49d |  |  |  | 23.77h |  | 475.33 | 465.57 |  |
| 24 | 1.2.3.1 | 2.3.1 - Authentification admin et monitoring | 10h | 2024-01-04 | 2024-01-06 | 14 |  |  | 2023-12-25 | 2024-01-01 | 9.51h | 142.79d |  |  | A_PE; D_DA | 13.77h |  | 275.33 | 265.57 |  |
| 25 | 1.2.3.2 | 2.3.2 - Interface utilisateur admin (Vues) | 10h | 2024-01-04 | 2024-01-06 | 14 |  |  | 2023-11-22 | 2023-12-01 | 10h | 140.54d |  |  | A_PI | 10h |  | 200 | 200 |  |

| ID | WBS | Task | Duration | Start | Finish | Predecessors | Complete | Remaining | Baseline start | Baseline finish | Baseline duration | Total slack | Free slack | Constraint | Resources | Work | Actual work | Cost | Baseline cost | Actual cost |
| --- | --- | --- | --- | --- | --- | --- | --- | --- | --- | --- | --- | --- | --- | --- | --- | --- | --- | --- | --- | --- |
| 26 | 1.2.4 | **2.4 - Base de données** | 125.65d | 2023-12-14 A | 2024-03-01 |  | 13% | 109.94d | 2023-12-13 | 2024-02-13 | 43.35d | 81.49d |  |  |  | 22h | 2.75h | 440 | 471 | 55 |
| 27 | 1.2.4.1 | 2.4.2 - Ajout des données | 2h | 2023-12-15 A | 2023-12-25 |  | 78% | 0.45h | 2023-12-15 | 2023-12-22 | 1.55h | 189.26d | 44.27d |  | A_PE; D_DA | 2h | 1.55h | 40 | 31 | 31 |
| 28 | 1.2.4.2 | 2.4.3 - Mise en place d'un système de backup | 12h | 2023-12-14 A | 2024-02-16 |  | 10% | 10.8h | 2023-12-14 | 2024-02-12 | 7.67h | 95.46d | 13.97d |  | A_PE; D_DA | 12h | 1.2h | 240 | 240 | 24 |
| 29 | 1.2.4.3 | 2.4.4 - Création des fonctions | 4h | 2024-01-15 | 2024-01-15 | 27 |  |  | 2023-12-15 | 2023-12-19 | 4h | 118.04d |  | start no earlier than 2024-01-15 | A_PI | 4h |  | 80 | 80 |  |
| 30 | 1.2.4.4 | 2.4.5 - Création des index | 4h | 2024-02-27 | 2024-03-01 | 27, 28 |  |  | 2024-02-12 | 2024-02-13 | 2h | 51.54d |  | start no earlier than 2024-02-27 | A_PE; D_DA | 4h |  | 80 | 80 |  |
| 31 | 1.2.5 | **2.6 - Integration continue et livraison continue (CI/ CD)** | 206.99d | 2023-12-15 A | 2024-04-15 |  | 16% | 173.55d | 2023-11-15 | 2024-02-26 | 72.66d | 0d |  |  |  | 107.8h | 29.36h | 2,156 | 1,480 | 587.1 |
| 32 | 1.2.5.1 | 2.6.1 - Tests - PHP | 15h | 2023-12-15 A | 2024-02-19 |  | 61% | 5.84h | 2023-11-15 | 2024-01-23 | 40h | 59.66d | 8.8d |  | A_PE; A_PI; D_DA; K_MO; P_LE | 19.8h | 13.96h | 396 | 960 | 279.1 |
| 33 | 1.2.5.2 | 2.6.2 - Tests | 30h | 2024-02-26 | 2024-03-06 | 32 |  |  |  |  |  | 50.86d | 5d | start no earlier than 2024-02-26 |  |  |  |  |  |  |
| 34 | 1.2.5.3 | 2.6.3 - Conteneurisation et déploiementc - PHP | 10h | 2023-12-25 A | 2024-01-03 |  | 28% | 7.2h | 2023-11-15 | 2024-01-23 | 8h | 163.99d | 59d |  | A_PE; D_DA | 10h | 2.8h | 200 | 160 | 56 |
| 35 | 1.2.5.4 | 2.6.4 - Conteneurisation et deploiement | 20h | 2024-02-05 | 2024-02-14 | 34 |  |  |  |  |  | 75.04d |  | start no earlier than 2024-02-05 | A_PE; D_DA | 20h |  | 400 |  |  |
| 36 | 1.2.5.5 | 2.6.5 - Documentations (swagger, schéma, …) PHP | 10h | 2024-03-11 A | 2024-04-09 | 32, 33 | 42% | 5.8h | 2024-01-23 | 2024-02-26 | 6h | 0d |  |  | A_PE; A_PI; D_DA | 24h | 12.6h | 480 | 360 | 252 |
| 37 | 1.2.5.6 | 2.6.6 - Documentations | 15h | 2024-04-09 | 2024-04-15 | 36 |  |  |  |  |  | 0d |  |  | D_DA; K_MO; P_LE | 34h |  | 680 |  |  |
